# Construction Schedule For Installation Of Condensate Storage Facility

Schedule from Primavera P6, 2018-05-10 to 2018-12-10, data date 2017-10-02.

## Calendars

- SR04 - 3 - 7 day week: Mon-Sun 08:00-12:00, 13:00-17:00. Exceptions (off unless hours are given): 2018-05-26 06:00-12:00, 13:00-19:00, 2018-06-14 to 2018-06-19, 2018-08-24 to 2018-08-29.
- PAPCO Cal.- 6 Days: Mon-Sat 08:00-12:00, 13:00-17:00; Sun off. Exceptions (off unless hours are given): 2018-06-15 to 2018-06-16, 2018-08-14 08:00-16:00, 2018-08-22 to 2018-08-24.

## Resources

| Resource | Group | Notes |
| --- | --- | --- |
| Manhours | labor | ?? |
| Job | equipment | ï»¿ |
| Running Meter | equipment | ï»¿ |
| Square Meter | equipment | ï»¿ |

## Schedule

| ID | WBS | Activity | Type | Duration | Start | Finish | Predecessors | Total float | Free float | Constraint | Resources |
| --- | --- | --- | --- | --- | --- | --- | --- | --- | --- | --- | --- |
|  | C | **Project Award** |  |  | 2018-05-10 | 2018-05-10 |  |  |  |  |  |
| A1000 |  | Award of Contract | milestone | 0d | 2018-05-10 | 2018-05-10 |  | -244d | 0d |  |  |
|  | 3 | **Engineering Phase** |  |  | 2018-05-18 | 2018-07-10 |  |  |  |  |  |
|  | 4 | **PROCESS DESIGN** |  |  | 2018-05-18 | 2018-06-04 |  |  |  |  |  |
| A1270 |  | DATASHEET FOR ESV, PCV & PSVS |  | 4.29d | 2018-05-18 | 2018-05-22 | A1000 | -209.29d | 0.71d | start on or after 2018-05-18 | Manhours [200 h]; Job [1 h] |
| A1220 |  | Piping & Instrumentation Diagram for Condensate Storage Tanks |  | 3d | 2018-05-22 | 2018-05-24 | A1270 FS-1d | -210d | 0d | start on or after 2018-05-22 | Manhours [180 h]; Job [1 h] |
| A1240 |  | Fire Ring Main Layout and Hydrant, Monitor Placement |  | 3d | 2018-05-22 | 2018-05-24 | A1270 FS-1d | 68.5d | 0.5d | start on or after 2018-05-22 | Job [1 h]; Manhours [220 h] |
| A1230 |  | Piping & Instrumentation Diagram condensate Loading System |  | 1d | 2018-05-24 | 2018-05-24 | A1220 FS-1d | -210d | 0d | start on or after 2018-05-24 | Job [1 h]; Manhours [200 h] |
| A1250 |  | Fire Fighting Design Report |  | 5d | 2018-05-31 | 2018-06-04 | A1240 FS+6d | 68d | 0d | start on or after 2018-05-31 | Job [1 h]; Manhours [220 h] |
|  | 1 | **Civil** |  |  | 2018-05-18 | 2018-06-26 |  |  |  |  |  |
| A1290 |  | CONDENSATE STORAGE TANK FOUNDATION DETAIL DRAWING |  | 1d | 2018-05-18 | 2018-05-18 | A1000 SS | -252d | 0d | start on or after 2018-05-18 | Job [1 h]; Manhours [170 h] |
| A1300 |  | CONDENSATE STORAGE TANK DYKE WALL DETAIL DRAWING |  | 1d | 2018-05-18 | 2018-05-18 | A1290 SS | 68.5d | 49d | start on or after 2018-05-18 | Manhours [180 h]; Job [1 h] |
| A1020 |  | GENERAL NOTES |  | 1d | 2018-05-24 | 2018-05-24 | A1290 FS+5d | -252d | 0d | start on or after 2018-05-24 | Job [1 h]; Manhours [200 h] |
| A1360 |  | GENERAL NOTES FOR STEEL STRUCTURAL WORKS |  | 1d | 2018-05-24 | 2018-05-24 | A1020 SS | -212d | 0.5d | start on or after 2018-05-24 | Manhours [150 h]; Job [1 h] |
| A1310 |  | CONDENSATE PUMP FOUNDATION DETAIL DRAWING |  | 1d | 2018-05-29 | 2018-05-29 | A1360 FS+4d | -212.5d | 0d | start on or after 2018-05-29 | Manhours [100 h]; Job [1 h] |
| A1320 |  | FOAM SKID FOUNDATION DETAIL DRAWING |  | 1d | 2018-05-29 | 2018-05-29 | A1310 SS | -212.5d | 0d | start on or after 2018-05-29 | Manhours [100 h]; Job [1 h] |
| A1330 |  | PIPE SUPPORTS FOUNDATION DETAIL DRAWING |  | 1d | 2018-05-31 | 2018-05-31 | A1320 FS+1d | -212.5d | 0d | start on or after 2018-05-31 | Job [1 h]; Manhours [120 h] |
| A1340 |  | PIPE SLEEPERS |  | 1d | 2018-05-31 | 2018-05-31 | A1330 SS | -212.5d | 0d | start on or after 2018-05-31 | Job [1 h]; Manhours [120 h] |
| A1350 |  | CROSSOVER FOUNDATION DETAIL DRAWING |  | 1d | 2018-05-31 | 2018-05-31 | A1340 SS | -212.5d | 0d | start on or after 2018-05-31 | Job [1 h]; Manhours [95 h] |
| A1370 |  | PIPE SUPPORTS STEEL STRUCTURE DETAIL DRAWING |  | 1d | 2018-06-04 | 2018-06-04 | A1350 FS+3d | -212.5d | 0d | start on or after 2018-06-04 | Job [1 h]; Manhours [150 h] |
| A1380 |  | CROSSOVER DETALS |  | 1d | 2018-06-04 | 2018-06-04 | A1350 FS+3d, A1370 SS | -212.5d | 0d | start on or after 2018-06-04 | Job [1 h]; Manhours [110 h] |
| A1280 |  | FOUNDATION LAYOUT |  | 1d | 2018-06-06 | 2018-06-06 | A1380 FS+1d | -212.5d | 39.5d | start on or after 2018-06-06 | Job [1 h]; Manhours [120 h] |
| A1790 |  | Submission of Drawings for Client Review and Approval |  | 14d | 2018-06-06 | 2018-06-26 | A1290 FS+19d | -212d | 1d | start on or after 2018-06-06 | Job [1 h]; Manhours [250 h] |
|  | 2 | **Mechanical** |  |  | 2018-05-22 | 2018-07-06 |  |  |  |  |  |
| A1030 |  | Plot Plan |  | 2d | 2018-05-22 | 2018-05-23 | A1390 SS | -232d | 0d | start on or after 2018-05-18 | Manhours [220 h]; Job [1 h] |
| A1390 |  | Key Plan |  | 4d | 2018-05-22 | 2018-05-25 | A1000 FS+12d | -232d | 0d |  | Job [1 h]; Manhours [190 h] |
| A1400 |  | Piping Layouts |  | 2.29d | 2018-05-23 | 2018-05-25 | A1390 SS+1d | -208.29d | 23.71d |  | Job [1 h]; Manhours [220 h] |
| A1420 |  | GENERAL ARRANGEMENT DRAWING FOR TANKS |  | 7d | 2018-05-28 | 2018-06-04 | A1230 FS+4d | -210d | 21d | start on or after 2018-05-25 | Job [1 h]; Manhours [200 h] |
| A1410 |  | FIRE WATER RING LAYOUT AND DETAILS |  | 1d | 2018-06-05 | 2018-06-05 | A1240 SF, A1250 | 68d | 19.5d | start on or after 2018-05-22 | Job [1 h]; Manhours [200 h] |
| A1430 |  | Isometric for Process Piping |  | 12d | 2018-06-23 | 2018-07-05 | A1030 FS+25d, A1400 | -232d | 0d |  | Job [1 h]; Manhours [320 h] |
| A1780 |  | Level Gauges Detail Drawings |  | 7d | 2018-06-23 | 2018-06-30 | A1430 SS | 157.5d |  |  | Job [1 h]; Manhours [120 h] |
| A1800 |  | Submission of Drawings for Client Review and Approval |  | 12d | 2018-06-23 | 2018-07-05 | A1030 FS+25d | 32.5d | 15.5d |  | Job [1 h]; Manhours [280 h] |
| A1520 |  | Piping stress Analysis |  | 5d | 2018-06-30 | 2018-07-04 | A1430 SS-2d | 153d |  | start on or after 2018-06-30 | Job [1 h]; Manhours [120 h] |
| A1440 |  | Isometric for Fire Water system |  | 4d | 2018-07-01 | 2018-07-05 | A1410, A1430 FS-4d | 48.5d | 0d | start on or after 2018-05-30 | Job [1 h]; Manhours [230 h] |
| A1890 |  | 3D Model |  | 5d | 2018-07-01 | 2018-07-06 | A1440 SS | 151.5d |  |  | Job [1 h]; Manhours [300 h] |

| ID | WBS | Activity | Duration | Start | Finish | Predecessors | Total float | Free float | Constraint | Resources |
| --- | --- | --- | --- | --- | --- | --- | --- | --- | --- | --- |
|  | 3 | **Electrical & Instrumentation** |  | 2018-05-28 | 2018-07-10 |  |  |  |  |  |
| A1580 |  | LIGHT POLE DETAIL DRAWINGS | 1d | 2018-05-28 | 2018-05-28 | A1220, A1230 FS+3d | 93d | 0d | start on or after 2018-05-28 | Job [1 h]; Manhours [100 h] |
| A1590 |  | ELECTRICAL DATASHEETS | 1d | 2018-05-28 | 2018-05-28 | A1270 FS+5d | 0d |  | start on or after 2018-05-28 | Job [1 h]; Manhours [120 h] |
| A1600 |  | EARTHING DETAILS | 1d | 2018-05-28 | 2018-05-28 | A1590 SS | 99d | 0d | start on or after 2018-05-28 | Job [1 h]; Manhours [100 h] |
| A1630 |  | ELECTRICAL CABLE TRAY AND TRENCH LAYOUT | 3d | 2018-05-29 | 2018-05-31 | A1510 FF | 0d |  | start on or after 2018-05-29 | Job [1 h]; Manhours [250 h] |
| A1510 |  | ELECTRICAL BOQ | 2d | 2018-05-30 | 2018-05-31 | A1590 FS+1d | 0d |  | start on or after 2018-05-30 | Job [1 h]; Manhours [200 h] |
| A1620 |  | EARTHING LAYOUT | 2d | 2018-05-30 | 2018-05-31 | A1600 FS+1d | 99d | 94d | start on or after 2018-05-28 | Job [1 h]; Manhours [250 h] |
| A1040 |  | DATASHEETS OF INSTRUMENTS | 1d | 2018-05-31 | 2018-05-31 | A1590 FS+2d | 181d |  | start on or after 2018-05-31 | Job [1 h]; Manhours [120 h] |
| A1540 |  | TYPICAL INSATALLATION DETAILS | 1d | 2018-05-31 | 2018-05-31 | A1510 SS | 0d |  | start on or after 2018-05-31 | Job [1 h]; Manhours [70 h] |
| A1550 |  | ELECTRICAL EARTHING TYPICAL INSTALLATION DETAILS | 1d | 2018-05-31 | 2018-05-31 | A1540 SS | 0d |  | start on or after 2018-05-31 | Job [1 h]; Manhours [160 h] |
| A1560 |  | HAZARDOUS AREA CLASSIFICATION DETAILS | 1d | 2018-05-31 | 2018-05-31 | A1550 SS | 0d |  | start on or after 2018-05-31 | Job [1 h]; Manhours [200 h] |
| A1570 |  | ELECTRICAL JUNCTION BOX DRAWING | 1d | 2018-05-31 | 2018-05-31 | A1540 SS, A1550 SS | 0d |  | start on or after 2018-05-31 | Job [1 h]; Manhours [200 h] |
| A1450 |  | INSTRUMENT LOCATION AND CABLE ROUTING LAYOUT | 4d | 2018-06-01 | 2018-06-04 | A1630, A1560 | 0d |  | start on or after 2018-05-23 | Job [1 h]; Manhours [60 h] |
| A1460 |  | INSTRUMENT CABLE SCHEDULE | 4d | 2018-06-01 | 2018-06-04 | A1450 FF | 0d |  | start on or after 2018-06-01 | Job [1 h]; Manhours [65 h] |
| A1470 |  | INSTRUMENT JB TERMINATION DRAWINGS | 2d | 2018-06-03 | 2018-06-04 | A1460 FF | 0d |  | start on or after 2018-06-02 | Job [1 h]; Manhours [80 h] |
| A1640 |  | LIGHTING PROTECTION LAYOUT | 1d | 2018-06-04 | 2018-06-04 | A1470 FS-1d | 123d |  | start on or after 2018-06-04 | Job [1 h]; Manhours [90 h] |
| A1650 |  | ELECTRICAL JUNCTION BOX DATASHEET | 1d | 2018-06-04 | 2018-06-04 | A1570 FS+3d | 0d |  | start on or after 2018-06-04 | Job [1 h]; Manhours [60 h] |
| A1480 |  | INSTRUMENT HOOKUP/STANDARD INSTRUMENT DRAWINGS | 4d | 2018-06-05 | 2018-06-08 | A1470, A1650 | 0d |  | start on or after 2018-06-04 | Job [1 h]; Manhours [70 h] |
| A1500 |  | INSTRUMENT MASTER INDEX | 3d | 2018-06-06 | 2018-06-08 | A1480 SS+1d | 0d |  | start on or after 2018-06-06 | Job [1 h]; Manhours [60 h] |
| A1810 |  | Submission of Drawings for Client Review and approval | 14d | 2018-06-07 | 2018-06-26 | A1580 FS+9d | 93d | 88d |  | Job [1 h]; Manhours [280 h] |
| A1490 |  | INSTRUMENT BOQ | 3d | 2018-06-08 | 2018-06-10 | A1500 SS+2d | 0d |  | start on or after 2018-06-06 | Job [1 h]; Manhours [90 h] |
| A1530 |  | ELECTRICAL LOAD LIST | 1d | 2018-06-10 | 2018-06-10 | A1510, A1490 FF | 124d | 0d | start on or after 2018-06-10 | Job [1 h]; Manhours [80 h] |
| A1610 |  | CATHODIC PROTECTION DRAWINGS AND CALCULATION | 1d | 2018-07-10 | 2018-07-10 | A1530 FF+24d | 124d | 37d | start on or after 2018-06-10 | Job [1 h]; Manhours [60 h] |
|  | 4 | **Procurement Phase** |  | 2018-06-21 | 2018-08-31 |  |  |  |  |  |
|  | 1 | **Civil** |  | 2018-06-21 | 2018-07-12 |  |  |  |  |  |
| A1050 |  | Procurement of Civil Builk material | 21d | 2018-06-21 | 2018-07-12 | A1020 FS+22d | -252d | 0d |  | Job [1 h]; Manhours [3850 h] |

| ID | WBS | Activity | Duration | Start | Finish | Predecessors | Total float | Free float | Constraint | Calendar | Resources |
| --- | --- | --- | --- | --- | --- | --- | --- | --- | --- | --- | --- |
|  | 2 | **Mechanical** |  | 2018-06-27 | 2018-07-14 |  |  |  |  |  |  |
| A1190 |  | Procurement of Piping builk Material (Including Fire water & 3" pipe Line) | 16d | 2018-06-27 | 2018-07-13 | A1060 SS-6d | -231d | 0d |  |  | Manhours [3300 h]; Job [1 h] |
| A1060 |  | Procurement of Tanks Plates | 11d | 2018-07-03 | 2018-07-14 | A1030 FS-3d, A1430 SS+10d | -231d | 0d |  |  | Job [1 h]; Manhours [3300 h] |
|  | 3 | **Electrical & Instrumentation** |  | 2018-06-24 | 2018-08-31 |  |  |  |  |  |  |
| A1820 |  | Procurement of Electrical | 55d | 2018-06-24 | 2018-08-17 | A1070 SS-3d | 103d |  |  |  | Job [1 h]; Manhours [2500 h] |
| A1070 |  | Procurement of Instrumentation | 60d | 2018-06-27 | 2018-08-31 | A1490 FS+10d | 0d |  |  |  | Job [1 h]; Manhours [2500 h] |
|  | 2 | **Mobilization** |  | 2018-06-21 | 2018-11-25 |  |  |  |  |  |  |
| A1010 |  | Mobiization of Civil Team | 3d | 2018-06-21 | 2018-06-24 | A1050 SS, A1290 | -224d | 0d | start on or after 2018-05-20 |  |  |
| A1660 |  | Mobiization of Mechanical Team | 6d | 2018-06-28 | 2018-07-04 | A1420 FS-3d, A1060 FS-34d, A1190 FS-15d | -231d | 1d | start on or after 2018-05-20 |  |  |
| A1680 |  | Mobiization of Crew for CP system Installation | 5d | 2018-08-17 | 2018-08-21 | A1610, CON88264 FS-5d | 87d | 0d | start on or after 2018-05-20 |  | Manhours |
| A1670 |  | Mobiization of Electrical & Instrumentation Team | 6d | 2018-09-01 | 2018-09-06 | A1070 | 5d | 0d | start on or after 2018-05-20 |  | Manhours |
| A1690 |  | Mobiization of Fire Water Line Crew | 3d | 2018-09-28 | 2018-10-01 | A1060 FS+70d, A1440 FS+70d | 39.5d | 0d | start on or after 2018-05-20 |  | Manhours |
| A1675 |  | Mobiization of Comssioning Team | 5d | 2018-11-21 | 2018-11-25 | CON88364 FS-10d | 7d |  | start on or after 2018-05-20 |  | Manhours |
|  | 26 | **Construction Phase** |  | 2018-06-21 | 2018-11-17 |  |  |  |  |  |  |
|  | 3 | **Civil Foundation Work** |  | 2018-06-21 | 2018-09-27 |  |  |  |  |  |  |
|  | 1 | **Storage Tank Foundation** |  | 2018-06-21 | 2018-08-05 |  |  |  |  |  |  |
| CON2001 |  | Layout & Marking | 1d | 2018-06-21 | 2018-06-22 | A1010 SS, A1020, A1790 FS-6d | -213d | 0d | start on 2017-11-15 |  | Job [1 h]; Manhours [300 h] |
| CON2010 |  | Excavation for Foundation | 5d | 2018-06-22 | 2018-06-28 | CON2001 | 16.5d | 0d |  | PAPCO Cal.- 6 Days | Manhours [1200 h]; Job [1 h] |
| CON2020 |  | Structural Fill & Compaction | 4d | 2018-06-25 | 2018-06-29 | CON2010 SS+2d | 16.5d | 0d |  | PAPCO Cal.- 6 Days | Manhours [1800 h]; Job [1 h] |
| CON2030 |  | Lean Concrete | 3d | 2018-06-27 | 2018-06-30 | CON2020 SS+2d | 16.5d | 0d |  | PAPCO Cal.- 6 Days | Manhours [1600 h]; Job [1 h] |
| CON2040 |  | Rebar cutting, fixing and placing for Base of Ring Foundation | 4d | 2018-07-03 | 2018-07-07 | CON2030 FS+2d | 16.5d | 0d |  | PAPCO Cal.- 6 Days | Manhours [1200 h]; Job [1 h] |
| CON2050 |  | Formwork for Base of Ring Foundation | 3d | 2018-07-09 | 2018-07-12 | CON2040 FS+1d | 16.5d | 0d |  | PAPCO Cal.- 6 Days | Manhours [1300 h]; Job [1 h] |
| CON2060 |  | Concrete pouring for Base of Ring Foundation | 3d | 2018-07-10 | 2018-07-13 | CON2050 SS+1d | 16.5d | 0d |  | PAPCO Cal.- 6 Days | Manhours [1800 h]; Job [1 h] |
| CON2070 |  | Rebar Placing & binding for Ring Wall | 6d | 2018-07-12 | 2018-07-19 | A1300, CON2060 SS+2d | 16.5d | 0d |  | PAPCO Cal.- 6 Days | Manhours [1500 h]; Job [1 h] |
| CON2080 |  | Formwork for Ring Wall | 4d | 2018-07-19 | 2018-07-24 | CON2070, CON2060 | 16.5d | 0d |  | PAPCO Cal.- 6 Days | Manhours [1000 h]; Job [1 h] |
| CON2090 |  | Concrete pouring for Ring Wall | 3d | 2018-07-20 | 2018-07-24 | CON2080 SS+1d | 16.5d | 0d |  | PAPCO Cal.- 6 Days | Manhours [2500 h]; Job [1 h] |
| CON2100 |  | Bituman Coating | 2d | 2018-07-25 | 2018-07-27 | CON2090 FS+1d, A1010 | 16.5d | 0d |  | PAPCO Cal.- 6 Days | Manhours [400 h]; Job [1 h] |
| CON2110 |  | Backfilling & Compaction | 2d | 2018-07-26 | 2018-07-28 | CON2100 FS-1d | 16.5d | 0d |  | PAPCO Cal.- 6 Days | Manhours [650 h]; Job [1 h] |
| CON2120 |  | Sand filling (In Layers ) | 3d | 2018-07-28 | 2018-07-31 | CON2110 | 19.5d | 0d |  |  | Job [1 h]; Manhours [1600 h] |
| CON2130 |  | Laying of Geo Membrane | 2d | 2018-07-31 | 2018-08-02 | CON2120 | 19.5d | 0d |  |  | Job [1 h]; Manhours [300 h] |
| CON2140 |  | Sand filling (Final Layer) | 3d | 2018-08-02 | 2018-08-05 | CON2130 | 19.5d | 0d |  |  | Job [1 h]; Manhours [560 h] |

| ID | WBS | Activity | Duration | Start | Finish | Predecessors | Total float | Free float | Constraint | Calendar | Resources |
| --- | --- | --- | --- | --- | --- | --- | --- | --- | --- | --- | --- |
|  | 6 | **Sump Pit** |  | 2018-08-11 | 2018-08-20 |  |  |  |  |  |  |
| A1830 |  | Layout | 1d | 2018-08-11 | 2018-08-12 | CON2140 FS+6d | 54.5d | 0d |  |  | Job [1 h]; Manhours [30 h] |
| A1840 |  | Excavation | 2d | 2018-08-12 | 2018-08-14 | A1830 | 86.5d | 0d |  |  | Job [1 h]; Manhours [40 h] |
| A1850 |  | Rebar Fixing & Formwork | 2d | 2018-08-14 | 2018-08-16 | A1840 | 86.5d | 0d |  |  | Job [1 h]; Manhours [40 h] |
| A1860 |  | Pouring of Concrete | 2d | 2018-08-16 | 2018-08-18 | A1850 | 86.5d | 0d |  |  | Job [16 h]; Manhours [120 h] |
| A1870 |  | Bitumen Coating | 1d | 2018-08-18 | 2018-08-19 | A1860 | 86.5d | 0d |  |  | Job [1 h]; Manhours [10 h] |
| A1880 |  | Backfilling | 1d | 2018-08-19 | 2018-08-20 | A1870 | 86.5d |  |  |  | Job [1 h]; Manhours [20 h] |
|  | 7 | **Dyke Wall** |  | 2018-08-11 | 2018-09-16 |  |  |  |  |  |  |
| A1900 |  | Layout | 1d | 2018-08-11 | 2018-08-12 | A1830 SS | 54.5d | 0d |  |  | Job [1 h]; Manhours [30 h] |
| A1910 |  | Excavation | 3d | 2018-08-11 | 2018-08-14 | A1900 SS | 54.5d | 0d |  |  | Job [1 h]; Manhours [200 h] |
| A1920 |  | Compaction & Lean Concrete | 4d | 2018-08-14 | 2018-08-18 | A1910 | 54.5d | 0d |  |  | Manhours [440 h]; Running Meter [117.2 h] |
| A1930 |  | Steel fixing and Formwork for Wall | 8d | 2018-08-18 | 2018-09-01 | A1920 | 54.5d | 0d |  |  | Running Meter [117.2 h]; Manhours [400 h] |
| A1940 |  | Pouring of Concrete | 10d | 2018-09-01 | 2018-09-11 | A1930 | 54.5d | 0d |  |  | Running Meter [117.2 h]; Manhours [720 h] |
| A1950 |  | Backfilling | 5d | 2018-09-11 | 2018-09-16 | A1940 | 54.5d | 0d |  |  | Running Meter [117.2 h]; Manhours [80 h] |
|  | 8 | **PCC Flooring** |  | 2018-09-16 | 2018-09-27 |  |  |  |  |  |  |
| A1960 |  | Leveling & Dressing | 3d | 2018-09-16 | 2018-09-19 | A1950 | 54.5d | 0d |  |  | Square Meter [805 h]; Manhours [120 h] |
| A1970 |  | Compaction | 5d | 2018-09-16 | 2018-09-21 | A1960 SS | 54.5d | 0d |  |  | Square Meter [805 h]; Manhours [160 h] |
| A1980 |  | Pouring of Concrete | 6d | 2018-09-21 | 2018-09-27 | A1970 | 54.5d |  |  |  | Square Meter [805 h]; Manhours [450 h] |
|  | 2 | **Foam Skid Foundation** |  | 2018-07-22 | 2018-08-03 |  |  |  |  |  |  |
| CON88394 |  | Layout & Marking | 1d | 2018-07-22 | 2018-07-23 | A1320, A1050 FS+10d, A1010, A1280 | -252d | 0d | start on 2017-11-15 |  | Manhours [8 h]; Job [1 h] |
| CON88404 |  | Excavation for Foundation | 1d | 2018-07-23 | 2018-07-24 | CON88394 | -218.5d | 0d |  | PAPCO Cal.- 6 Days | Manhours [16 h]; Job [1 h] |
| CON88414 |  | Structural Fill & Compaction | 2d | 2018-07-23 | 2018-07-25 | CON88404 FS-1d | -218.5d | 0d | start on or after 2018-06-24 | PAPCO Cal.- 6 Days | Manhours [16 h]; Job [1 h] |
| CON88424 |  | Lean Concrete | 1d | 2018-07-25 | 2018-07-26 | CON88414 | -218.5d | 0d |  | PAPCO Cal.- 6 Days | Manhours [16 h]; Job [1 h] |
| CON88434 |  | Rebar placing for Foundation | 2d | 2018-07-26 | 2018-07-28 | CON88424 | 87.5d | 0d |  | PAPCO Cal.- 6 Days | Manhours [12 h]; Job [1 h] |
| CON88444 |  | Formwork for Foundation | 1d | 2018-07-28 | 2018-07-30 | CON88434 | 87.5d | 0d |  | PAPCO Cal.- 6 Days | Manhours [12 h]; Job [1 h] |
| CON88464 |  | Concrete pouring for Foundation | 1d | 2018-07-30 | 2018-07-31 | CON88444 | 87.5d | 0d |  | PAPCO Cal.- 6 Days | Manhours [80 h]; Job [1 h] |
| CON88494 |  | Bituman Coating | 1d | 2018-07-31 | 2018-08-01 | CON88464 | 87.5d | 0d |  | PAPCO Cal.- 6 Days | Manhours [6 h]; Job [1 h] |
| CON88504 |  | Backfilling | 2d | 2018-08-01 | 2018-08-03 | CON88494 | 87.5d | 0d |  | PAPCO Cal.- 6 Days | Manhours [16 h]; Job [1 h] |

| ID | WBS | Activity | Duration | Start | Finish | Predecessors | Total float | Free float | Constraint | Calendar | Resources |
| --- | --- | --- | --- | --- | --- | --- | --- | --- | --- | --- | --- |
|  | 3 | **Condensate Pump Foundation** |  | 2018-07-26 | 2018-08-14 |  |  |  |  |  |  |
| CON88514 |  | Layout & Marking | 1d | 2018-07-26 | 2018-07-27 | A1310, CON88424, A1280 | -252d | 0d | start on 2017-11-15 |  | Manhours [6 h]; Job [1 h] |
| CON88524 |  | Excavation for Foundation | 1d | 2018-07-27 | 2018-07-28 | CON88514 | 95.5d | 0d |  | PAPCO Cal.- 6 Days | Manhours [8 h]; Job [1 h] |
| CON88534 |  | Structural Fill & Compaction | 2d | 2018-07-30 | 2018-08-01 | CON88524 FS+1d | 95.5d | 0d |  | PAPCO Cal.- 6 Days | Manhours [30 h]; Job [1 h] |
| CON88544 |  | Lean Concrete | 1d | 2018-08-01 | 2018-08-02 | CON88534 | 95.5d | 0d |  | PAPCO Cal.- 6 Days | Manhours [30 h]; Job [1 h] |
| CON88554 |  | Rebar placing for Foundation | 2d | 2018-08-04 | 2018-08-07 | CON88544 FS+2d | 95.5d | 0d |  | PAPCO Cal.- 6 Days | Manhours [20 h]; Job [1 h] |
| CON88564 |  | Formwork for Foundation | 2d | 2018-08-07 | 2018-08-09 | CON88554 | 95.5d | 0d | start on or after 2018-07-08 | PAPCO Cal.- 6 Days | Manhours [20 h]; Job [1 h] |
| CON88574 |  | Concrete pouring for Foundation | 1d | 2018-08-09 | 2018-08-10 | CON88564 | 95.5d | 0d |  | PAPCO Cal.- 6 Days | Manhours [160 h]; Job [1 h] |
| CON88584 |  | Bituman Coating | 1d | 2018-08-10 | 2018-08-11 | CON88574 | 95.5d | 0d |  | PAPCO Cal.- 6 Days | Manhours [6 h]; Job [1 h] |
| CON88594 |  | Backfilling | 2d | 2018-08-11 | 2018-08-14 | CON88584 | 95.5d | 0d |  | PAPCO Cal.- 6 Days | Manhours [16 h]; Job [1 h] |
|  | 4 | **Crossover Foundation** |  | 2018-07-29 | 2018-08-11 |  |  |  |  |  |  |
| CON88604 |  | Layout & Marking | 1d | 2018-07-29 | 2018-07-30 | A1350, CON88514 FS+2d, A1280 | -252d | 0d | start on 2017-11-15 |  | Manhours [8 h]; Job [1 h] |
| CON88614 |  | Excavation for Foundation | 1d | 2018-07-30 | 2018-07-31 | CON88604 | -218.5d | 0d |  | PAPCO Cal.- 6 Days | Manhours [12 h]; Job [1 h] |
| CON88624 |  | Structural Fill & Compaction | 2d | 2018-07-31 | 2018-08-02 | CON88614 | -218.5d | 0d |  | PAPCO Cal.- 6 Days | Manhours [8 h]; Job [1 h] |
| CON88634 |  | Lean Concrete | 1d | 2018-08-02 | 2018-08-03 | CON88624 | 71.5d | 0d |  | PAPCO Cal.- 6 Days | Manhours [8 h]; Job [1 h] |
| CON88644 |  | Rebar placing for Foundation | 2d | 2018-08-03 | 2018-08-06 | CON88634 | 71.5d | 0d |  | PAPCO Cal.- 6 Days | Manhours [12 h]; Job [1 h] |
| CON88654 |  | Formwork for Foundation | 1d | 2018-08-06 | 2018-08-07 | CON88644 | 71.5d | 0d |  | PAPCO Cal.- 6 Days | Manhours [8 h]; Job [1 h] |
| CON88664 |  | Concrete pouring for Foundation | 2d | 2018-08-07 | 2018-08-09 | CON88654 | 71.5d | 0d |  | PAPCO Cal.- 6 Days | Manhours [150 h]; Job [1 h] |
| CON88674 |  | Bituman Coating | 1d | 2018-08-09 | 2018-08-10 | CON88664 | 71.5d | 0d |  | PAPCO Cal.- 6 Days | Manhours [6 h]; Job [1 h] |
| CON88684 |  | Backfilling | 1d | 2018-08-10 | 2018-08-11 | CON88674 | 71.5d | 37.5d |  | PAPCO Cal.- 6 Days | Manhours [12 h]; Job [1 h] |
|  | 5 | **Pipe Supports and Sleepers** |  | 2018-07-30 | 2018-08-29 |  |  |  |  |  |  |
| CON88694 |  | Layout & Marking | 2d | 2018-07-30 | 2018-08-01 | A1330, CON88624 FS-3d, A1280 | -252d | 0d | start on 2017-11-15 |  | Manhours [20 h]; Job [1 h] |
| CON88704 |  | Excavation | 4d | 2018-07-31 | 2018-08-04 | CON88694 SS+1d | 31.5d | 0d |  | PAPCO Cal.- 6 Days | Manhours [120 h]; Job [1 h] |
| CON88714 |  | Structural Fill & Compaction | 5d | 2018-08-01 | 2018-08-07 | CON88704 SS+1d | 31.5d | 0d |  | PAPCO Cal.- 6 Days | Manhours [80 h]; Job [1 h] |
| CON88724 |  | Lean Concrete | 4d | 2018-08-03 | 2018-08-08 | CON88714 SS+2d | 31.5d | 0d |  | PAPCO Cal.- 6 Days | Manhours [120 h]; Job [1 h] |
| CON88734 |  | Rebar Cutting, Fixing & Placment | 4d | 2018-08-06 | 2018-08-10 | CON88724 SS+2d | 31.5d | 0d |  | PAPCO Cal.- 6 Days | Manhours [90 h]; Job [1 h] |
| CON88744 |  | Formwork | 5d | 2018-08-08 | 2018-08-14 | CON88734 SS+2d | 31.5d | 0d |  | PAPCO Cal.- 6 Days | Manhours [100 h]; Job [1 h] |
| CON88754 |  | Concrete pouring | 5d | 2018-08-14 | 2018-08-20 | CON88744 | 31.5d | 0d |  | PAPCO Cal.- 6 Days | Manhours [400 h]; Job [1 h] |
| CON88764 |  | Bituman Coating | 2d | 2018-08-20 | 2018-08-25 | CON88754 | 31.5d | 0d |  | PAPCO Cal.- 6 Days | Manhours [20 h]; Job [1 h] |
| CON88774 |  | Backfilling | 3d | 2018-08-25 | 2018-08-29 | CON88764 | 31.5d | 12.5d |  | PAPCO Cal.- 6 Days | Manhours [80 h]; Job [1 h] |

| ID | WBS | Activity | Duration | Start | Finish | Predecessors | Total float | Free float | Constraint | Calendar | Resources |
| --- | --- | --- | --- | --- | --- | --- | --- | --- | --- | --- | --- |
|  | 9 | **Culvert (Main Interence of GPF-I)** |  | 2018-07-10 | 2018-07-27 |  |  |  |  |  |  |
| CON89204 |  | Layout & Marking | 1d | 2018-07-10 | 2018-07-11 | CON89094 SS+4d | -232d | 0d | start on 2017-11-15 |  | Manhours [20 h]; Job [1 h] |
| CON89214 |  | Excavation | 1d | 2018-07-11 | 2018-07-12 | CON89204 SS+1d | 96.5d | 0d |  | PAPCO Cal.- 6 Days | Manhours [50 h]; Job [1 h] |
| CON89224 |  | Structural Fill & Compaction | 1d | 2018-07-12 | 2018-07-13 | CON89214 SS+1d | 96.5d | 0d |  | PAPCO Cal.- 6 Days | Manhours [30 h]; Job [1 h] |
| CON89234 |  | Lean Concrete | 1d | 2018-07-13 | 2018-07-14 | CON89224 | 96.5d | 0d |  | PAPCO Cal.- 6 Days | Manhours [60 h]; Job [1 h] |
| CON89244 |  | Rebar Cutting, Fixing & Placment for Wall | 2d | 2018-07-16 | 2018-07-18 | CON89234 FS+1d | 96.5d | 0d |  | PAPCO Cal.- 6 Days | Manhours [50 h]; Job [1 h] |
| CON89254 |  | Formwork for Wall | 1d | 2018-07-18 | 2018-07-19 | CON89244 | 96.5d | 0d |  | PAPCO Cal.- 6 Days | Manhours [40 h]; Job [1 h] |
| CON89264 |  | Concrete pouring for wall | 1d | 2018-07-19 | 2018-07-20 | CON89254 | 96.5d | 0d |  | PAPCO Cal.- 6 Days | Manhours [120 h]; Job [1 h] |
| CON89294 |  | Rebar Cutting, Fixing & Placment for Roof | 2d | 2018-07-20 | 2018-07-23 | CON89264 | 96.5d | 0d |  | PAPCO Cal.- 6 Days | Job [1 h]; Manhours [60 h] |
| CON89304 |  | Formwork for Roof | 1d | 2018-07-23 | 2018-07-24 | CON89294 | 96.5d | 0d |  | PAPCO Cal.- 6 Days | Job [1 h]; Manhours [80 h] |
| CON89314 |  | Concrete pouring for Roof | 1d | 2018-07-24 | 2018-07-25 | CON89304 | 96.5d | 0d |  | PAPCO Cal.- 6 Days | Job [1 h]; Manhours [130 h] |
| CON89274 |  | Bituman Coating | 1d | 2018-07-25 | 2018-07-26 | CON89314 | 96.5d | 0d |  | PAPCO Cal.- 6 Days | Manhours [22 h]; Job [1 h] |
| CON89284 |  | Backfilling | 1d | 2018-07-26 | 2018-07-27 | CON89274 | 96.5d |  |  | PAPCO Cal.- 6 Days | Manhours [80 h]; Job [1 h] |
|  | 6 | **MECHANICAL Work** |  | 2018-07-05 | 2018-11-02 |  |  |  |  |  |  |
|  | 3 | **Fabrication of Tanks** |  | 2018-07-09 | 2018-09-22 |  |  |  |  |  |  |
| CON87954 |  | Fabrication & Welding of Annular Plates & Bottom Plates | 15d | 2018-07-09 | 2018-07-25 | A1030, A1060 SS+5d, A1420, A1660, A1800 SS | 15d | 0d | start on or after 2018-06-02 | PAPCO Cal.- 6 Days | Manhours [2100 h]; Job [1 h] |
| CON87974 |  | Fabrication & Rolling of Shell Plates | 21d | 2018-07-09 | 2018-08-01 | CON87954 SS | 15d | 0d |  | PAPCO Cal.- 6 Days | Manhours [2800 h]; Job [1 h] |
| CON87964 |  | Sand Blasting / Prime coating of Annular & Bottom Plates | 7d | 2018-07-19 | 2018-07-26 | CON87954 SS+9d | 29d | 13d |  | PAPCO Cal.- 6 Days | Manhours [560 h]; Job [1 h] |
| CON87984 |  | Sand Blasting / Prime coating of Shell Plates | 10d | 2018-08-02 | 2018-08-13 | CON87964 FF+1d, CON87974 | 15d | 0d |  | PAPCO Cal.- 6 Days | Manhours [800 h]; Job [1 h] |
| CON87994 |  | Fabrication of Roof Plates | 10d | 2018-08-02 | 2018-08-13 | CON87974 | 18d | 0d |  | PAPCO Cal.- 6 Days | Manhours [1650 h]; Job [1 h] |
| CON88054 |  | Radiography / NDT of T Joints | 5d | 2018-08-05 | 2018-08-09 | CON87994 SS+3d | 25d | 10d |  |  | Job [1 h]; Manhours [300 h] |
| CON88004 |  | Sand Blasting / Prime coating of Roof Plates | 7d | 2018-08-08 | 2018-08-15 | CON87994 SS+5d | 18d | 3d |  | PAPCO Cal.- 6 Days | Manhours [560 h]; Job [1 h] |
| CON88014 |  | Wind Girder / Curb Angle rolling | 7d | 2018-08-14 | 2018-08-21 | CON87994 SS, CON87984 | 15d | 0d |  | PAPCO Cal.- 6 Days | Manhours [510 h]; Job [1 h] |
| CON88024 |  | Sand Blasting / Prime coating of Wind Girder / Curb Angle | 6d | 2018-08-20 | 2018-08-29 | CON88014 SS+5d, CON88054, CON88004 | 15d | 0d |  | PAPCO Cal.- 6 Days | Manhours [480 h]; Job [1 h] |
| CON88034 |  | Tank Structure Fabrication | 15d | 2018-08-30 | 2018-09-15 | CON88024 | 15d | 0d |  | PAPCO Cal.- 6 Days | Manhours [1800 h]; Job [1 h] |
| CON88044 |  | Tank Structure Sand Blasting / Prime coating | 10d | 2018-09-12 | 2018-09-22 | CON88034 SS+11d | 15d | 0d |  | PAPCO Cal.- 6 Days | Manhours [680 h]; Job [1 h] |

| ID | WBS | Activity | Duration | Start | Finish | Predecessors | Total float | Free float | Calendar | Resources |
| --- | --- | --- | --- | --- | --- | --- | --- | --- | --- | --- |
|  | 4 | **Erection Work Tanks** |  | 2018-08-06 | 2018-11-02 |  |  |  |  |  |
| CON88264 |  | Erection of Annular & Bottom Plates | 15d | 2018-08-06 | 2018-08-25 | CON87964 FS-5d, CON2140 | 19d | 0d | PAPCO Cal.- 6 Days | Manhours [4500 h]; Job [1 h] |
| CON88274 |  | Erection of Shell Cources | 17d | 2018-08-10 | 2018-09-01 | CON88264 SS+4d | 19d | 0d | PAPCO Cal.- 6 Days | Manhours [7500 h]; Job [1 h] |
| CON88284 |  | Erection of Tank Structure / Wind Girder / Curb Angle | 16d | 2018-08-14 | 2018-09-04 | CON88274 FS-14d | 33d | 18d | PAPCO Cal.- 6 Days | Manhours [1800 h]; Job [1 h] |
| CON88304 |  | Erection of Nozzles and Manholes | 13d | 2018-08-15 | 2018-09-01 | CON88274 SS+4d | 19d | 0d | PAPCO Cal.- 6 Days | Manhours [2000 h]; Job [1 h] |
| CON88294 |  | Erection of Roof Structure / Plates | 19d | 2018-09-12 | 2018-10-03 | CON88284 FS-12d, CON88044 SS | 15d | 0d | PAPCO Cal.- 6 Days | Manhours [1800 h]; Job [1 h] |
| CON88314 |  | Erection of Ladder Platform | 17d | 2018-09-20 | 2018-10-09 | CON88304 FS-3d, CON88344 SS-12d | 15d | 0d | PAPCO Cal.- 6 Days | Manhours [1600 h]; Job [1 h] |
| CON88334 |  | Final Painting Internal & External | 15d | 2018-10-01 | 2018-10-17 | CON88314 FS-8d | 15d | 0d | PAPCO Cal.- 6 Days | Manhours [1400 h]; Job [1 h] |
| CON88344 |  | VBT of Bottom | 6d | 2018-10-04 | 2018-10-10 | CON88294 | 15d | 0d | PAPCO Cal.- 6 Days | Manhours [500 h]; Job [1 h] |
| CON88354 |  | Hydrostatic Test | 8d | 2018-10-12 | 2018-10-20 | CON88334 FS-5d | 15d | 0d | PAPCO Cal.- 6 Days | Manhours [1200 h]; Job [1 h] |
| CON88454 |  | Third Party Calibration of Tanks | 15d | 2018-10-19 | 2018-11-02 | CON88354 FS-2d | 18d |  |  | Job [1 h]; Manhours [450 h] |
|  | Surface Piping | **Surface Piping** |  | 2018-07-05 | 2018-10-11 |  |  |  |  |  |
|  | 1 | **3" Pipe line to GPF-1 Tanks** |  | 2018-07-05 | 2018-07-28 |  |  |  |  |  |
| CON89094 |  | Fabrication of Piping | 6d | 2018-07-05 | 2018-07-12 | A1660, A1190 FS-10d, A1430 | -201.5d | 0d | PAPCO Cal.- 6 Days | Manhours [600 h]; Job [1 h] |
| CON89104 |  | Welding of Piping | 6d | 2018-07-06 | 2018-07-13 | CON89094 SS+1d | 98.5d | 0d | PAPCO Cal.- 6 Days | Manhours [600 h]; Job [1 h] |
| CON89114 |  | Radiography | 4d | 2018-07-10 | 2018-07-14 | CON89104 FF+1d | 98.5d | 0d | PAPCO Cal.- 6 Days | Manhours [140 h]; Job [1 h] |
| CON89124 |  | Blasting & Initial Painting | 5d | 2018-07-10 | 2018-07-16 | CON89114 FF+1d | 98.5d | 0d | PAPCO Cal.- 6 Days | Manhours [200 h]; Job [1 h] |
| CON89164 |  | Excavation | 5d | 2018-07-10 | 2018-07-15 | CON89124 SS | 123.5d | 8d |  | Job [1 h]; Manhours [400 h] |
| CON89184 |  | Coating of Line (Under Ground Section) | 6d | 2018-07-10 | 2018-07-16 | CON89114 SS, CON89124 SS | 115.5d | 0d |  | Job [1 h]; Manhours [100 h] |
| CON89134 |  | Installation / Erection | 4d | 2018-07-16 | 2018-07-20 | CON89124 | 98.5d | 0d | PAPCO Cal.- 6 Days | Manhours [150 h]; Job [1 h] |
| CON89174 |  | Lowering & Holiday Testing | 2d | 2018-07-18 | 2018-07-20 | CON89184 FS+2d, CON89164 SS | 115.5d | 3d |  | Job [1 h]; Manhours [100 h] |
| CON89144 |  | Hydrotesting | 2d | 2018-07-20 | 2018-07-23 | CON89134 | 98.5d | 0d | PAPCO Cal.- 6 Days | Manhours [1 h]; Manhours [120 h] |
| CON89154 |  | Final Painting of above ground piping | 5d | 2018-07-23 | 2018-07-28 | CON89144 | 112.5d |  | PAPCO Cal.- 6 Days | Manhours [90 h]; Job [1 h] |
| CON89194 |  | Backfilling | 2d | 2018-07-23 | 2018-07-25 | CON89174, CON89144 | 112.5d |  |  | Job [1 h]; Manhours [130 h] |

| ID | WBS | Activity | Duration | Start | Finish | Predecessors | Total float | Free float | Calendar | Resources |
| --- | --- | --- | --- | --- | --- | --- | --- | --- | --- | --- |
|  | Surface Piping | **Surface Piping** |  | 2018-08-15 | 2018-10-11 |  |  |  |  |  |
| CON88864 |  | Fabrication of Piping | 15d | 2018-08-15 | 2018-09-04 | A1430, CON88304 SS | 19d | 0d | PAPCO Cal.- 6 Days | Manhours [830 h]; Job [1 h] |
| CON88874 |  | Welding of Piping | 15d | 2018-08-16 | 2018-09-05 | CON88864 SS+1d | 34d | 0d | PAPCO Cal.- 6 Days | Manhours [830 h]; Job [1 h] |
| CON88884 |  | Radiography | 10d | 2018-08-27 | 2018-09-06 | CON88874 FF+1d | 34d | 0d | PAPCO Cal.- 6 Days | Manhours [180 h]; Job [1 h] |
| CON88894 |  | Blasting & Initial Painting | 4d | 2018-09-05 | 2018-09-08 | CON88884 FF+2d | 34d | 0d | PAPCO Cal.- 6 Days | Manhours [290 h]; Job [1 h] |
| CON88904 |  | Installation / Erection | 12d | 2018-09-10 | 2018-09-22 | CON88894 | 34d | 0d | PAPCO Cal.- 6 Days | Manhours [480 h]; Job [1 h] |
| CON89004 |  | Hydrotesting | 6d | 2018-09-24 | 2018-09-29 | CON88904 | 34d | 0d | PAPCO Cal.- 6 Days | Manhours [190 h]; Job [1 h] |
| CON88914 |  | Final Painting | 10d | 2018-10-01 | 2018-10-11 | CON89004 | 34d |  | PAPCO Cal.- 6 Days | Manhours [160 h]; Job [1 h] |
|  | Surface Piping1 | **Structural work** |  | 2018-08-27 | 2018-10-11 |  |  |  |  |  |
|  | 1 | **Pipe Supports** |  | 2018-08-27 | 2018-09-27 |  |  |  |  |  |
| CON88924 |  | Fabrication and Welding | 10d | 2018-08-27 | 2018-09-06 | CON88864 FS-8d, A1370 | 19d | 0d | PAPCO Cal.- 6 Days | Manhours [400 h]; Job [1 h] |
| CON88934 |  | Blasting & Painting | 5d | 2018-09-07 | 2018-09-12 | CON88924 | 19d | 0d | PAPCO Cal.- 6 Days | Manhours [1 h]; Manhours [180 h] |
| CON88944 |  | Installation | 5d | 2018-09-13 | 2018-09-18 | CON88934, CON88774 | 19d | 0d | PAPCO Cal.- 6 Days | Manhours [180 h]; Job [1 h] |
| CON88954 |  | Final Painting | 8d | 2018-09-19 | 2018-09-27 | CON88944 | 46d |  | PAPCO Cal.- 6 Days | Manhours [220 h]; Job [1 h] |
|  | 2 | **Crossovers** |  | 2018-09-07 | 2018-10-11 |  |  |  |  |  |
| CON88964 |  | Fabrication and Welding | 12d | 2018-09-07 | 2018-09-20 | CON88924, A1350 | 34d | 0d | PAPCO Cal.- 6 Days | Manhours [280 h]; Job [1 h] |
| CON88974 |  | Blasting & Painting | 6d | 2018-09-21 | 2018-09-27 | CON88964 | 34d | 0d | PAPCO Cal.- 6 Days | Manhours [180 h]; Job [1 h] |
| CON88984 |  | Erection | 4d | 2018-09-28 | 2018-10-02 | CON88974, CON88684 | 34d | 0d | PAPCO Cal.- 6 Days | Manhours [90 h]; Job [1 h] |
| CON88994 |  | Final Painting | 8d | 2018-10-03 | 2018-10-11 | CON88984 | 34d |  | PAPCO Cal.- 6 Days | Manhours [100 h]; Job [1 h] |
|  | 1 | **Erection of Equipments and Skids** |  | 2018-08-03 | 2018-08-17 |  |  |  |  |  |
|  | 1 | **Foam Skid** |  | 2018-08-03 | 2018-08-07 |  |  |  |  |  |
| CON89014 |  | Placement | 1d | 2018-08-03 | 2018-08-04 | CON88504, A1060 | 87.5d | 0d | PAPCO Cal.- 6 Days | Manhours [30 h]; Job [1 h] |
| CON89024 |  | Leveling & Alligment | 1d | 2018-08-04 | 2018-08-06 | CON89014 | 87.5d | 0d | PAPCO Cal.- 6 Days | Manhours [25 h]; Job [1 h] |
| CON89054 |  | Grouting | 1d | 2018-08-06 | 2018-08-07 | CON89024 | 87.5d |  | PAPCO Cal.- 6 Days | Manhours [20 h]; Job [1 h] |

| ID | WBS | Activity | Duration | Start | Finish | Predecessors | Total float | Free float | Calendar | Resources |
| --- | --- | --- | --- | --- | --- | --- | --- | --- | --- | --- |
|  | 2 | **Condensate Pump** |  | 2018-08-14 | 2018-08-17 |  |  |  |  |  |
| CON89064 |  | Placement | 1d | 2018-08-14 | 2018-08-15 | CON89014, CON88594, A1060 | 95.5d | 0d | PAPCO Cal.- 6 Days | Manhours [30 h]; Job [1 h] |
| CON89074 |  | Leveling & Alligment | 1d | 2018-08-15 | 2018-08-16 | CON89064 | 95.5d | 0d | PAPCO Cal.- 6 Days | Manhours [20 h]; Job [1 h] |
| CON89084 |  | Grouting | 1d | 2018-08-16 | 2018-08-17 | CON89074 | 95.5d | 96.5d | PAPCO Cal.- 6 Days | Manhours [18 h]; Job [1 h] |
|  | 2 | **Fire Water and Foam System** |  | 2018-10-01 | 2018-10-20 |  |  |  |  |  |
| CON88784 |  | Material Shifting to Site | 2d | 2018-10-01 | 2018-10-03 | A1440, A1690 | 34.5d | 0d | PAPCO Cal.- 6 Days | Manhours [150 h]; Job [1 h] |
| CON88794 |  | Fabrication | 8d | 2018-10-03 | 2018-10-12 | CON88784 | 34.5d | 0d | PAPCO Cal.- 6 Days | Manhours [450 h]; Job [1 h] |
| CON88804 |  | Welding | 8d | 2018-10-04 | 2018-10-13 | CON88794 SS+1d | 34.5d | 0d | PAPCO Cal.- 6 Days | Manhours [450 h]; Job [1 h] |
| CON88814 |  | Excavation for Fire water line | 6d | 2018-10-08 | 2018-10-14 | CON88804 SS+3d | 57.5d |  |  | Job [1 h]; Manhours [120 h] |
| CON88854 |  | NDT & Coating | 5d | 2018-10-09 | 2018-10-15 | CON88804 FF+1d | 34.5d | 0d | PAPCO Cal.- 6 Days | Manhours [200 h]; Job [1 h] |
| CON88834 |  | Lowering, Holiday testing and Back filling of fire water line | 5d | 2018-10-13 | 2018-10-18 | CON88854 FS-1d | 40.5d | 0d |  | Job [1 h]; Manhours [80 h] |
| CON88824 |  | Hydrotesting | 2d | 2018-10-18 | 2018-10-20 | CON88834 | 34.5d |  | PAPCO Cal.- 6 Days | Manhours [80 h]; Job [1 h] |
|  | 1 | **Electrical & Instrumentation Work** |  | 2018-08-22 | 2018-11-17 |  |  |  |  |  |
|  | 4 | **CP System Installation** |  | 2018-08-22 | 2018-09-14 |  |  |  |  |  |
| A1760 |  | Installation of CP System | 18d | 2018-08-22 | 2018-09-14 | A1680 | 87d | 95d |  | Job [1 h]; Manhours [350 h] |
|  | 1 | **Earthing Work** |  | 2018-09-15 | 2018-10-05 |  |  |  |  |  |
| A1700 |  | Earth Boring | 5d | 2018-09-15 | 2018-09-19 | A1670 FS+8d, A1070, A1600, A1620, A1810 SS | 5d | 0d |  | Job [1 h]; Manhours [100 h] |
| A1710 |  | Installation of Earth Rod | 4d | 2018-09-20 | 2018-09-23 | A1700 | 5d | 0d |  | Manhours [50 h]; Job [1 h] |
| A1720 |  | Earth Resistance Testing | 2d | 2018-09-24 | 2018-09-25 | A1710 | 5d | 0d |  | Job [1 h]; Manhours [40 h] |
| A1730 |  | Excavation for Earth cable | 4d | 2018-09-26 | 2018-09-29 | A1710 FS+1d, A1720 | 5d | 0d |  | Job [1 h]; Manhours [80 h] |
| A1770 |  | Laying of Earth cable | 4d | 2018-09-27 | 2018-09-30 | A1730 SS+1d | 5d | 0d |  | Manhours [150 h]; Job [1 h] |
| A1740 |  | Backfilling for Earthing Cable | 5d | 2018-09-28 | 2018-10-02 | A1770 SS+1d | 5d | 0d |  | Job [1 h]; Manhours [40 h] |
| A1750 |  | Termination including Cable lugs, Coper, Crimp | 7d | 2018-09-29 | 2018-10-05 | A1740 SS+1d | 5d |  |  | Job [1 h]; Manhours [30 h] |
|  | Electrical | **Electrical Work** |  | 2018-10-11 | 2018-11-17 |  |  |  |  |  |
| A1080 |  | Cable Tray Installation | 8d | 2018-10-11 | 2018-10-18 | A1070 FS+40d, CON88944, A1770 SS, A1750, A1820 SS | 0d |  |  | Job [1 h]; Manhours [200 h] |
| A1100 |  | Excavation for Cable Laying | 8d | 2018-10-14 | 2018-10-21 | A1080 FS-5d | 0d |  |  | Job [1 h]; Manhours [90 h] |
| A1110 |  | Meggering of Cable | 3d | 2018-10-17 | 2018-10-19 | A1090 SS-1d | 11d |  |  | Job [1 h]; Manhours [24 h] |
| A1090 |  | Laying of Electrical Cable | 8d | 2018-10-18 | 2018-10-25 | A1100 SS+4d, A1640, A1820 SS | 0d |  |  | Job [1 h]; Manhours [150 h] |
| A1120 |  | Installation of Lights | 5d | 2018-10-31 | 2018-11-04 | A1090 FS+5d, A1580, A1640, A1110 | 0d |  |  | Manhours [60 h]; Job [1 h] |
| A1130 |  | Glanding & Termination | 6d | 2018-11-06 | 2018-11-11 | A1120 FS+1d | 0d |  |  | Job [1 h]; Manhours [48 h] |
| A1140 |  | Loop Testing | 5d | 2018-11-13 | 2018-11-17 | A1130 FS+1d | 0d |  |  | Job [1 h]; Manhours [100 h] |

| ID | WBS | Activity | Duration | Start | Finish | Predecessors | Total float | Free float | Constraint | Calendar | Resources |
| --- | --- | --- | --- | --- | --- | --- | --- | --- | --- | --- | --- |
|  | 2 | **Instrumentation System** |  | 2018-10-14 | 2018-11-12 |  |  |  |  |  |  |
| A1150 |  | Excavation for Cable Laying | 5d | 2018-10-14 | 2018-10-18 | A1100 SS | 29d | 0d |  |  | Job [1 h]; Manhours [100 h] |
| A1160 |  | Cable Laying | 8d | 2018-10-17 | 2018-10-24 | A1150 FS-2d | 29d | 0d |  |  | Job [1 h]; Manhours [150 h] |
| A1180 |  | Instrument Installation | 6d | 2018-10-23 | 2018-10-28 | A1160 FS-2d | 29d | 0d |  |  | Job [1 h]; Manhours [80 h] |
| A1200 |  | Glanding & Termination | 6d | 2018-10-23 | 2018-10-28 | A1180 SS | 29d | 0d |  |  | Job [1 h]; Manhours [60 h] |
| A1210 |  | Loop Testing | 5d | 2018-10-29 | 2018-11-02 | A1200 | 29d |  |  |  | Job [1 h]; Manhours [70 h] |
| A1170 |  | Installation of Tubing | 8d | 2018-11-05 | 2018-11-12 | A1120, A1160 | 28d |  |  |  | Job [1 h]; Manhours [64 h] |
|  | 1 | **Project Completion Phase** |  | 2018-11-21 | 2018-12-10 |  |  |  |  |  |  |
| CON88364 |  | Punch Listing | 10d | 2018-11-21 | 2018-12-01 | CON88914, CON88334 FS-5d, CON88954, CON88994, CON88824 FS-8d, CON89054, CON89084 FS-18d, A1740, A1140 FS+3d, A1210 FF, A1760 SS-10d, CON88354 FF-2d, CON89194, CON88454, A1880, A1950, A1980, CON89284 | 0d |  | start on or after 2018-10-10 | PAPCO Cal.- 6 Days | Manhours [300 h]; Job [1 h] |
| CON88384 |  | Comssioning | 5d | 2018-12-03 | 2018-12-07 | CON88364, A1675 | 0d |  | start on or after 2018-10-10 | PAPCO Cal.- 6 Days | Manhours [340 h]; Job [1 h] |
| CON88374 |  | Demoblization | 5d | 2018-12-05 | 2018-12-10 | CON88384 SS+2d | 0d |  |  | PAPCO Cal.- 6 Days | Manhours [80 h]; Job [1 h] |
